# WBS5_sched_19MAR2007

Schedule from MS Project, 2007-03-19 to 2009-07-31.
PPPL

## Calendars

- Standard: Mon-Fri 08:00-12:00, 13:00-17:00; Sat-Sun off.

## Resources

| Resource | Unit |
| --- | --- |
| ECH*EM |  |
| ECH*SB |  |
| EMT*TB |  |
| EADDSB |  |
| 41 | K |
| TRNG | K |
| TRVL | K |
| EED*TB |  |
| EED*EM |  |

## Schedule

| ID | WBS | Task | Type | Duration | Start | Finish | Predecessors | Total slack | Free slack | Constraint | Resources | Work |
| --- | --- | --- | --- | --- | --- | --- | --- | --- | --- | --- | --- | --- |
| 1 | --- | Startup Testing 22JAN09 | milestone | 1d | 2009-01-22 | 2009-01-22 |  | 136d |  | start no earlier than 2009-01-22 |  |  |
| 2 | --- | CD-4 11MAR09 | milestone | 0d | 2009-03-11 | 2009-03-11 |  | 103d |  | start no earlier than 2009-03-11 |  |  |
| 3 | '--- | NSTX Run Support |  | 135d? | 2007-12-03 | 2008-06-06 |  | 300d |  | finish no earlier than 2008-06-06 |  |  |
| 5 | 51 | WBS51 - Networking Infrastructure |  | 1d? | 2007-03-19 | 2007-03-19 |  | 619d |  |  |  |  |
| 6 | 51-10 | Preliminary Design |  | 30d | 2007-10-01 | 2007-11-09 |  | 0d |  | must start on 2007-10-01 | ECH*EM [3000%] | 7200h |
| 7 | 51-20 | Final Design |  | 60d | 2007-11-12 | 2008-02-01 | 6 | 286d | 0d |  | ECH*EM [3000%] | 14400h |
| 8 | 51-30 | Procurement |  | 60d | 2008-02-04 | 2008-04-25 | 7 | 330d |  |  | ECH*EM [2000%]; 41 [39 K] | 9600h |
| 9 | 51-50 | Installation |  | 60d | 2008-04-28 | 2008-07-18 | 8 | 256d | 0d |  | ECH*EM [6000%]; EMT*TB [49000%]; EADDSB [24000%]; ECH*SB [2000%] | 388800h |
| 10 | 51-60 | Test |  | 14d | 2008-07-21 | 2008-08-07 | 9 | 256d |  |  | ECH*EM [2000%]; ECH*SB [2000%] | 4480h |
| 12 | 52 | WBS52 - Central I&C |  | 1d? | 2007-03-19 | 2007-03-19 |  | 619d |  |  |  |  |
| 13 | 52-10 | Preliminary Design |  | 30d | 2007-11-01 | 2007-12-12 |  | 0d |  | must start on 2007-11-01 | ECH*EM [4000%] | 9600h |
| 14 | 52-20 | Final Design |  | 60d | 2007-12-13 | 2008-03-05 | 13 | 237d | 0d |  | ECH*EM [4000%] | 19200h |
| 15 | 52-30 | Procurement |  | 30d | 2008-03-06 | 2008-04-16 | 14 | 237d | 0d |  | ECH*EM [2000%]; 41 [38 K] | 4800h |
| 16 | 52-40 | EPICS Programming - Base |  | 10d | 2008-04-17 | 2008-04-30 | 15 | 237d | 0d |  | ECH*EM [8000%] | 6400h |
| 17 | 52-50 | EPICS Programming - VDCT db editor |  | 30d | 2008-05-01 | 2008-06-11 | 16 | 297d |  |  | ECH*EM [4000%] | 9600h |
| 18 | 52-60 | IOC Programming - MDSplus I/O & events |  | 30d | 2008-05-01 | 2008-06-11 | 16 | 297d |  | start no earlier than 2008-05-01 | ECH*EM [12000%] | 28800h |
| 19 | 52-70 | OPC - EPICS/PLC Interface (T/C) |  | 90d | 2008-05-01 | 2008-09-03 | 16 | 237d |  | start no earlier than 2008-05-01 | ECH*EM [16000%]; 41 [2 K]; TRVL [2 K] | 115200h |
| 20 | 52-80 | Programming - misc. |  | 90d | 2007-03-19 | 2007-07-20 |  | 530d |  |  | ECH*EM [10000%] | 72000h |
| 21 | 52-90 | Installation |  | 60d | 2008-04-17 | 2008-07-09 | 15 | 277d |  |  | ECH*EM [4000%]; EMT*TB [24000%]; EADDSB [12000%]; ECH*SB [10000%] | 240000h |
| 22 | 52-100 | Test |  | 14d | 2007-03-19 | 2007-04-05 |  | 606d |  |  | ECH*EM [4000%] | 4480h |
| 24 | 53 | WBS53 - Data Acquisition & Management |  | 1d? | 2007-03-19 | 2007-03-19 |  | 619d |  |  |  |  |
| 25 | 53-10 | Preliminary Design |  | 30d | 2007-10-15 | 2007-11-23 |  | 0d |  | must start on 2007-10-15 | ECH*EM [4000%] | 9600h |
| 26 | 53-20 | Final Design |  | 30d | 2007-11-26 | 2008-01-04 | 25 | 240d | 0d |  | ECH*EM [8000%] | 19200h |
| 27 | 53-30 | Procurement |  | 30d | 2008-01-07 | 2008-02-15 | 26 | 240d | 0d |  | ECH*EM [2000%]; 41 [22 K] | 4800h |
| 28 | 53-40 | Installation |  | 30d | 2008-02-18 | 2008-03-28 | 27 | 240d | 0d |  | ECH*SB [4000%] | 9600h |
| 29 | 53-50 | MDSplus Installation |  | 20d | 2008-03-31 | 2008-04-25 | 28 | 240d | 0d |  | ECH*EM [8000%] | 12800h |
| 30 | 53-60 | MDSplus Programming - Tree Design |  | 20d | 2008-04-28 | 2008-05-23 | 29 | 240d | 0d |  | ECH*EM [8000%] | 12800h |
| 31 | 53-70 | MDSplus Programming - Shot Sync |  | 20d | 2008-05-26 | 2008-06-20 | 30 | 240d | 0d | start no earlier than 2008-05-19 | ECH*EM [8000%] | 12800h |
| 32 | 53-80 | MDSplus Programming - Dispatcher |  | 30d | 2008-06-23 | 2008-08-01 | 31 | 240d | 0d | start no earlier than 2008-05-19 | ECH*EM [16000%] | 38400h |
| 33 | 53-90 | MDSplus Programming - Acquisition |  | 20d | 2008-08-04 | 2008-08-29 | 32 | 240d |  | start no earlier than 2008-05-19 | ECH*EM [8000%] | 12800h |
| 34 | 53-110 | Programming - Misc. |  | 60d | 2007-03-19 | 2007-06-08 |  | 560d |  |  | ECH*EM [16000%] | 76800h |
| 35 | 53-120 | Test |  | 14d | 2007-10-15 | 2007-11-01 |  | 456d |  | start no earlier than 2007-10-15 | ECH*EM [4000%]; ECH*SB [4000%] | 8960h |
| 37 | 54 | WBS54 - Facility Timing & Synch. |  | 1d? | 2007-03-19 | 2007-03-19 |  | 619d |  | start no earlier than 2007-03-19 |  |  |
| 38 | 54-10 | Preliminary System Design |  | 30d | 2007-10-01 | 2007-11-09 |  | 216d | 0d | start no earlier than 2007-10-01 | ECH*EM [4000%] | 9600h |
| 39 | 54-20 | Final SystemDesign |  | 40d | 2007-11-12 | 2008-01-04 | 38 | 216d | 0d | start no earlier than 2007-03-19 | ECH*EM [4000%] | 12800h |
| 40 | 54-30 | Preliminary Design - Clock Dist. |  | 20d | 2007-11-12 | 2007-12-07 | 38 | 400d | 0d |  | ECH*EM [2000%]; EED*EM [4000%] | 9600h |
| 41 | 54-40 | Final Design - Clock Dist. |  | 30d | 2007-12-10 | 2008-01-18 | 40 | 400d |  |  | ECH*EM [2000%]; EED*EM [12000%] | 33600h |
| 42 | 54-50 | Test - Clock Dist. |  | 40d | 2008-05-12 | 2008-07-04 | 43 | 280d |  |  | ECH*EM [2000%]; EED*TB [12000%]; EED*EM [10000%] | 76800h |
| 43 | 54-60 | Procurement |  | 90d | 2008-01-07 | 2008-05-09 | 39 | 216d | 0d | start no earlier than 2007-12-18 | ECH*EM [4000%]; 41 [34 K] | 28800h |
| 44 | 54-70 | UNT - Timing & Seq Emulation (FPGA Pgm) |  | 90d | 2007-10-01 | 2008-02-01 |  | 390d |  | start no earlier than 2007-10-01 | ECH*SB [16000%] | 115200h |
| 45 | 54-80 | UNT - Device Driver Prog (EPICS/MDSplus) |  | 120d | 2008-03-12 | 2008-08-26 | 39 | 213d | 0d | start no earlier than 2008-03-12 | ECH*EM [16000%] | 153600h |
| 46 | 54-90 | Central Clock (EPICS) Programming |  | 30d | 2008-08-27 | 2008-10-07 | 45 | 213d |  |  | ECH*EM [8000%] | 19200h |
| 47 | 54-100 | Installation |  | 90d | 2008-05-12 | 2008-09-12 | 43 | 216d | 0d | start no earlier than 2007-06-11 | ECH*EM [4000%]; ECH*SB [8000%]; EMT*TB [12000%]; EADDSB [4000%] | 201600h |
| 48 | 54-110 | Test |  | 14d | 2008-09-15 | 2008-10-02 | 47 | 216d |  | start no earlier than 2007-10-15 | ECH*EM [4000%]; ECH*SB [4000%] | 8960h |
| 50 | 55 | WBS55 - Real Time Control |  | 1d? | 2007-03-19 | 2007-03-19 |  | 619d |  | start no earlier than 2007-03-19 |  |  |
| 51 | 55-10 | FCPC - Preliminary Design |  | 30d | 2008-01-25 | 2008-03-06 |  | 172d | 0d | start no earlier than 2008-01-25 | ECH*EM [4000%] | 9600h |
| 52 | 55-20 | FCPC -Final Design |  | 60d | 2008-03-07 | 2008-05-29 | 51 | 172d | 0d | start no earlier than 2007-03-19 | ECH*EM [8000%] | 38400h |
| 53 | 55-30 | FCPC - Procurement |  | 60d | 2008-05-30 | 2008-08-21 | 52 | 172d | 0d | start no earlier than 2007-06-11 | ECH*EM [2000%]; 41 [14 K] | 9600h |
| 54 | 55-40 | LabVIEW Programming |  | 30d | 2008-08-18 | 2008-09-26 | 61 | 220d |  |  | ECH*EM [12000%] | 28800h |
| 55 | 55-50 | FCPC PLC Integration - EPICS Prog. |  | 30d | 2008-08-18 | 2008-09-26 | 61 | 220d |  |  | ECH*EM [4000%] | 9600h |
| 56 | 55-50 | FCPC - Installation |  | 60d | 2008-08-22 | 2008-11-13 | 53 | 172d | 0d | start no earlier than 2007-06-11 | ECH*EM [4000%]; ECH*SB [4000%]; EADDSB [8000%] | 76800h |
| 57 | 55-60 | FCPC -Test |  | 14d | 2008-11-14 | 2008-12-03 | 56 | 172d |  | start no earlier than 2007-10-15 | ECH*EM [4000%]; ECH*SB [2000%] | 6720h |
| 58 | 55-70 | GISRTC - Preliminary Design |  | 30d | 2007-12-10 | 2008-01-18 |  | 176d | 0d | start no earlier than 2007-12-10 | ECH*EM [4000%] | 9600h |
| 59 | 55-80 | GISRTC -Final Design |  | 60d | 2008-01-21 | 2008-04-11 | 58 | 176d | 0d | start no earlier than 2007-03-19 | ECH*EM [6000%] | 28800h |
| 60 | 55-90 | GISRTC - Procurement |  | 60d | 2008-04-14 | 2008-07-04 | 59 | 176d | 0d | start no earlier than 2007-06-11 | ECH*EM [2000%]; 41 [12 K] | 9600h |
| 61 | 55-100 | LabVIEW Programming |  | 30d | 2008-07-07 | 2008-08-15 | 60 | 176d | 0d |  | ECH*EM [12000%] | 28800h |
| 62 | 55-110 | GISRTC - Installation |  | 60d | 2008-08-18 | 2008-11-07 | 61 | 176d | 0d | start no earlier than 2007-06-11 | ECH*EM [2000%]; ECH*SB [2000%]; EADDSB [2400%] | 30720h |
| 63 | 55-120 | GISRTC -Test |  | 14d | 2008-11-10 | 2008-11-27 | 62 | 176d |  | start no earlier than 2007-10-15 | ECH*EM [2000%] | 2240h |
| 65 | 56 | WBS56 - Central Safety & Interlocks |  | 1d? | 2007-03-19 | 2007-03-19 |  | 619d |  | start no earlier than 2007-03-19 |  |  |
| 66 | 56-10 | Requirements, Codes&Standards |  | 60d | 2007-12-03 | 2008-02-22 |  | 0d |  | must start on 2007-12-03 | ECH*EM [4000%] | 19200h |
| 67 | 56-20 | Preliminary Design |  | 30d | 2008-02-25 | 2008-04-04 | 66 | 155d | 0d | start no earlier than 2007-10-29 | ECH*EM [4000%] | 9600h |
| 68 | 56-30 | PLC Training |  | 60d | 2008-04-07 | 2008-06-27 | 67 | 285d |  |  | ECH*EM [8000%]; 41 [2 K]; TRVL [2 K] | 38400h |
| 69 | 56-40 | Final Design |  | 30d | 2008-04-07 | 2008-05-16 | 67 | 155d | 0d | start no earlier than 2007-03-19 | ECH*EM [14000%] | 33600h |
| 70 | 56-40 | Procurement |  | 60d | 2008-05-19 | 2008-08-08 | 69 | 155d | 0d | start no earlier than 2007-06-11 | ECH*EM [4000%]; 41 [40 K] | 19200h |
| 71 | 56-50 | PLC Programming |  | 90d | 2008-08-11 | 2008-12-12 | 70 | 165d |  |  | ECH*EM [12000%] | 86400h |
| 72 | 56-60 | Installation |  | 70d | 2008-08-11 | 2008-11-14 | 70 | 155d | 0d | start no earlier than 2008-06-12 | ECH*EM [6000%]; EMT*TB [48000%]; ECH*SB [8000%]; EADDSB [24000%] | 481600h |
| 73 | 56-70 | Test |  | 30d | 2008-11-17 | 2008-12-26 | 72 | 155d |  | start no earlier than 2008-10-23 | ECH*EM [8000%]; ECH*SB [4000%] | 28800h |
| 75 | 57-10 | WBS57 - NCSX Control Room |  | 1d? | 2007-03-19 | 2007-03-19 |  | 619d |  | start no earlier than 2007-03-19 |  |  |
| 77 | 58-10 | WBS58 -FY07 Management & Integration |  | 130d | 2007-04-02 | 2007-09-28 |  | 0d |  | must finish on 2007-09-28 | ECH*EM [12000%] | 124800h |
| 78 | 58-20 | WBS58 -FY08 Management & Integration |  | 262d | 2007-10-01 | 2008-09-30 |  | 0d |  | must start on 2007-10-01 | ECH*EM [12000%] | 251520h |

| ID | WBS | Task | Duration | Start | Finish | Total slack | Constraint | Resources | Work |
| --- | --- | --- | --- | --- | --- | --- | --- | --- | --- |
| 79 | 58-30 | WBS58 -FY09 Management & Integration | 218d | 2008-10-01 | 2009-07-31 | 0d | must start on 2008-10-01 | ECH*EM [12000%] | 209280h |
