# proj1

Schedule from MS Project, 2007-04-30 to 2008-12-26.
PPPL

## Calendars

- Standard: Mon-Fri 08:00-12:00, 13:00-17:00; Sat-Sun off.

## Schedule

| ID | WBS | Task | Type | Duration | Start | Finish | Predecessors | Total slack | Free slack | Constraint | Deadline |
| --- | --- | --- | --- | --- | --- | --- | --- | --- | --- | --- | --- |
| 1 | 1 | WBS5 |  | 1d? | 2007-04-30 | 2007-04-30 |  | 434d |  |  |  |
| 3 | 2 | WBS51 - Network and Fiber Optic Infrastructure |  | 224d | 2007-10-01 | 2008-08-07 |  | 101d |  | finish no earlier than 2008-08-07 |  |
| 4 | 3 | WBS52 - Central Instrumentation and Control |  | 220d | 2007-11-01 | 2008-09-03 |  | 82d |  | finish no earlier than 2008-09-03 |  |
| 5 | 4 | WBS53 - Data Acquisition and Facility Computing |  | 290d | 2007-10-15 | 2008-11-21 |  | 25d |  | finish no earlier than 2008-11-21 |  |
| 6 | 5 | WBS54 - Facility Timing and Synchronization |  | 264d | 2007-10-04 | 2008-10-07 | 9 | 58d |  | finish no earlier than 2008-10-07 |  |
| 7 | 6 | WBS55 - Real Time Plasma and Power Supply Control |  | 220d | 2008-01-25 | 2008-11-27 |  | 21d |  | finish no earlier than 2008-11-27 |  |
| 8 | 7 | WBS56 - Central Safety and Interlock System |  | 280d | 2007-12-03 | 2008-12-26 |  | 0d |  | finish no earlier than 2008-12-26 |  |
| 9 | 8 | WBS57 - Control Room Facility | milestone | 0d | 2007-10-01 | 2007-10-01 |  | -109d | 0d | start no earlier than 2007-10-01 | 2007-04-30 |
